# CSF Upgrades and Migrations

Schedule from MS Project, 2013-01-14 to 2014-01-13, A marks actual dates.
MIT

## Calendars

- Standard: Mon-Fri 08:00-12:00, 13:00-17:00; Sat-Sun off.

## Resources

| Resource |
| --- |
| Dave |
| René |
| Steve |
| Felicia |
| Ram |
| Kevin |
| Brian |
| Janet |
| Seth |
| Lee |
| Faith |
| Peter |
| Debra |
| Frank Q. |
| Jack |
| Leo |
| Carrie |
| Roberta |

## Schedule

| ID | WBS | Task | Type | Duration | Start | Finish | Predecessors | Complete | Baseline start | Baseline finish | Baseline duration | Resources | Work | Actual work |
| --- | --- | --- | --- | --- | --- | --- | --- | --- | --- | --- | --- | --- | --- | --- |
| 1 | 1 | Upgrade CSF to 2.0 |  | 10d | 2013-01-14 A | 2013-01-25 A |  | 100% |  |  |  |  |  |  |
| 2 | 2 | **Upgrade of Existing CSF Apps to CSF 2.0** |  | 46d | 2013-02-13 A | 2013-04-17 A |  | 100% | 2013-02-13 | 2013-03-08 | 18d? |  | 257.6h | 257.6h |
| 3 | 2.1 | **Development** |  | 11d | 2013-02-13 A | 2013-02-27 A |  | 100% | 2013-02-13 | 2013-03-08 | 18d |  | 64h | 64h |
| 4 | 2.1.1 | Upgrade IAP |  | 7d | 2013-02-14 A | 2013-02-25 A | 1FS+13d | 100% | 2013-02-14 | 2013-02-20 | 4d | Steve [50%] | 28h | 28h |
| 5 | 2.1.2 | Upgrade Subject Evaluation Report/OSE Report |  | 1d | 2013-02-26 A | 2013-02-26 A | 4FS+3d | 100% | 2013-02-26 | 2013-03-01 | 4d | Steve [50%] | 4h | 4h |
| 6 | 2.1.3 | Upgrade Sponsor Billing |  | 4d | 2013-02-13 A | 2013-02-19 A | 1FS+12d | 100% | 2013-02-13 | 2013-02-19 | 4d | Dave [50%] | 16h | 16h |
| 7 | 2.1.4 | Upgrade Survey Engine |  | 2d | 2013-02-26 A | 2013-02-27 A | 6FS+4d | 100% | 2013-02-26 | 2013-03-01 | 4d | Dave [50%] | 8h | 8h |
| 8 | 2.1.5 | Upgrade Response Rate Report |  | 2d | 2013-02-22 A | 2013-02-25 A | 7FS+1d | 100% | 2013-03-05 | 2013-03-08 | 4d | Dave [50%] | 8h | 8h |
| 9 | 2.1.6 | Upgrades complete | milestone | 0d | 2013-02-27 A | 2013-02-27 A | 4, 5, 6, 7, 8 | 100% | 2013-03-08 | 2013-03-08 | 0d | Dave [50%]; Steve [50%] |  |  |
| 10 | 2.2 | **Testing** |  | 30d | 2013-02-20 A | 2013-04-02 A |  | 100% |  |  |  |  | 113.6h | 113.6h |
| 11 | 2.2.1 | **Test Planning** |  | 8d | 2013-02-20 A | 2013-03-01 A |  | 100% |  |  |  |  | 31.6h | 31.6h |
| 12 | 2.2.1.1 | Sponsor Billing |  | 3d | 2013-02-20 A | 2013-02-22 A | 4SS+4d | 100% |  |  |  | Seth [25%]; Faith [25%] | 7.6h | 7.6h |
| 13 | 2.2.1.2 | OSE Applications |  | 3d | 2013-02-27 A | 2013-03-01 A | 12FS+2d | 100% |  |  |  | Lee | 24h | 24h |
| 14 | 2.2.1.3 | Test Planning Complete | milestone | 0d | 2013-03-01 A | 2013-03-01 A | 12, 13 | 100% |  |  |  |  |  |  |
| 15 | 2.2.2 | **BA Testing** |  | 27d | 2013-02-25 A | 2013-04-02 A |  | 100% |  |  |  |  | 82h | 82h |
| 16 | 2.2.2.1 | Sponsor Billing |  | 3d | 2013-02-25 A | 2013-02-27 A | 12 | 100% |  |  |  | Faith [25%] | 6h | 6h |
| 17 | 2.2.2.2 | IAP (includes planning) |  | 22d | 2013-03-04 A | 2013-04-02 A | 16FS+2d | 100% |  |  |  | Seth [25%] | 44h | 44h |
| 18 | 2.2.2.3 | OSE Applications |  | 4d | 2013-03-04 A | 2013-03-07 A | 13 | 100% |  |  |  | Lee | 32h | 32h |
| 19 | 2.2.2.4 | BA Testing Complete | milestone | 0d | 2013-03-28 A | 2013-03-28 A | 16, 18, 17 | 100% |  |  |  |  |  |  |
| 20 | 2.2.3 | **UAT** |  | 4d | 2013-03-04 A | 2013-03-07 A |  | 100% |  |  |  |  |  |  |
| 21 | 2.2.3.1 | OSE Applications |  | 4d | 2013-03-04 A | 2013-03-07 A | 18SS | 100% |  |  |  |  |  |  |
| 22 | 2.2.3.2 | UAT Complete | milestone | 0d | 2013-03-07 A | 2013-03-07 A | 21 | 100% |  |  |  |  |  |  |
| 23 | 2.2.4 | Testing Efforts Complete | milestone | 0d | 2013-03-28 A | 2013-03-28 A | 14, 19, 22 | 100% |  |  |  |  |  |  |
| 24 | 2.3 | **Deployment Preparation** |  | 11d | 2013-04-03 A | 2013-04-17 A |  | 100% |  |  |  |  | 80h | 80h |
| 25 | 2.3.1 | Get business approval for IAP |  | 10d | 2013-04-03 A | 2013-04-17 A | 17 | 100% |  |  |  | Seth | 80h | 80h |

| ID | WBS | Task | Type | Duration | Start | Finish | Predecessors | Complete | Remaining | Baseline start | Baseline finish | Baseline duration | Total slack | Free slack | Constraint | Resources | Work | Actual work |
| --- | --- | --- | --- | --- | --- | --- | --- | --- | --- | --- | --- | --- | --- | --- | --- | --- | --- | --- |
| 26 | 2.4 | **Go-live** |  | 35d | 2013-02-28 A | 2013-04-17 A |  | 100% |  |  |  |  |  |  |  |  |  |  |
| 27 | 2.4.1 | Sponsor Billing |  | 1d | 2013-02-28 A | 2013-02-28 A | 16FS+2d | 100% |  |  |  |  |  |  |  |  |  |  |
| 28 | 2.4.2 | IAP | milestone | 0d | 2013-04-17 A | 2013-04-17 A | 17FS+2d, 25 | 100% |  |  |  |  |  |  |  |  |  |  |
| 29 | 2.4.3 | OSE Applications |  | 1d | 2013-03-07 A | 2013-03-08 A | 18, 21 | 100% |  |  |  |  |  |  |  |  |  |  |
| 30 | 2.5 | Upgrade of Existing CSF Apps to CSF 2.0 Complete | milestone | 0d | 2013-04-17 A | 2013-04-17 A | 27, 28, 29 | 100% |  |  |  |  |  |  |  |  |  |  |
| 31 | 3 | **Convert SAIS-Common Apps to CSF 2.0** |  | 211.5d | 2013-03-22 A | 2014-01-13 |  | 57% | 91.73d | 2013-06-11 | 2014-01-13 | 154.5d | 0d |  |  |  | 1004.04h | 515.04h |
| 32 | 3.1 | **Batch Admin** |  | 40d | 2013-03-22 A | 2013-05-16 A |  | 100% |  |  |  |  |  |  |  |  | 68h | 68h |
| 33 | 3.1.1 | Development |  | 23d | 2013-03-22 A | 2013-04-24 A |  | 100% |  |  |  |  |  |  |  | Steve [25%] | 46h | 46h |
| 34 | 3.1.2 | Do file comparison |  | 2d | 2013-04-25 A | 2013-04-26 A | 33 | 100% |  |  |  |  |  |  |  | Steve [25%] | 4h | 4h |
| 35 | 3.1.3 | Do SAP testing - iteration 1 |  | 1d | 2013-05-03 A | 2013-05-03 A | 34FS+5d | 100% |  |  |  |  |  |  |  | Frank Q. [25%] | 2h | 2h |
| 36 | 3.1.4 | **Deployment Preparation** |  | 7d | 2013-05-06 A | 2013-05-14 A |  | 100% |  |  |  |  |  |  |  |  | 16h | 16h |
| 37 | 3.1.4.1 | Get business approval |  | 1d | 2013-05-06 A | 2013-05-06 A | 35 | 100% |  |  |  |  |  |  |  | René [25%] | 2h | 2h |
| 38 | 3.1.4.2 | Create deployment plan |  | 7d | 2013-05-06 A | 2013-05-14 A | 35 | 100% |  |  |  |  |  |  |  | René [25%] | 14h | 14h |
| 39 | 3.1.5 | Go-live | milestone | 0d | 2013-05-16 A | 2013-05-16 A | 38FS+2d | 100% |  |  |  |  |  |  |  |  |  |  |
| 40 | 3.2 | **Bundle 1 (Advisor Assignment, Instructor Assignment, Supervisor Assignment, and Reg Control List)** |  | 164.5d | 2013-05-28 A | 2014-01-13 |  | 49% | 84.21d | 2013-06-11 | 2014-01-13 | 154.5d | 0d |  |  |  | 936.04h | 447.04h |
| 41 | 3.2.1 | **Development** |  | 27d | 2013-05-28 A | 2013-07-03 A |  | 100% |  |  |  |  |  |  |  |  | 95.04h | 95.04h |
| 42 | 3.2.1.1 | Convert Advisor Assignment |  | 9d | 2013-05-28 A | 2013-06-07 A |  | 100% |  |  |  |  |  |  | start no earlier than 2013-05-28 | Dave [33%] | 23.76h | 23.76h |
| 43 | 3.2.1.2 | Convert Supervisor Assignment |  | 9d | 2013-06-10 A | 2013-06-20 A | 42 | 100% |  |  |  |  |  |  |  | Dave [33%] | 23.76h | 23.76h |
| 44 | 3.2.1.3 | Convert Instructor Assignment |  | 9d | 2013-06-21 A | 2013-07-03 A | 43 | 100% |  |  |  |  |  |  |  | Dave [33%] | 23.76h | 23.76h |
| 45 | 3.2.1.4 | Convert Reg Control List |  | 9d | 2013-05-28 A | 2013-06-07 A | 42SS | 100% |  |  |  |  |  |  |  | Steve [33%] | 23.76h | 23.76h |
| 46 | 3.2.1.5 | Bundle 1 development complete | milestone | 0d | 2013-07-03 A | 2013-07-03 A | 44, 45, 42, 43 | 100% |  |  |  |  |  |  |  |  |  |  |
| 47 | 3.2.2 | **Testing** |  | 115d | 2013-06-11 A | 2013-11-18 |  | 43% | 65.46d | 2013-06-11 | 2013-10-30 | 102d | 39.5d |  |  |  | 796h | 352h |
| 48 | 3.2.2.1 | **Regression Testing** |  | 104d | 2013-06-11 A | 2013-11-01 |  | 48% | 54.2d | 2013-06-11 | 2013-10-30 | 102d | 50.5d |  |  |  | 324h | 176h |
| 49 | 3.2.2.1.1 | Test Advisor Assignment |  | 10d | 2013-06-11 A | 2013-06-24 A | 42FS+1d | 100% |  | 2013-06-11 | 2013-06-24 | 10d |  |  |  | Jack | 80h | 80h |
| 50 | 3.2.2.1.2 | Test Instructor Assignment |  | 21d | 2013-08-28 A | 2013-09-26 A | 49, 44 | 100% |  | 2013-08-28 | 2013-09-25 | 20d |  |  | start no earlier than 2013-08-28 | Jack [50%] | 84h | 84h |
| 51 | 3.2.2.1.3 | Test Supervisor Assignment |  | 24d | 2013-09-30 A | 2013-11-01 | 50FS+1d, 43 | 13% | 21d | 2013-09-26 | 2013-10-30 | 24d | 30d | 0d |  | Jack [50%] | 96h | 12h |
| 52 | 3.2.2.1.4 | Test Reg Control List |  | 16d | 2013-09-03 | 2013-09-24 | 45 |  |  | 2013-09-03 | 2013-09-04 | 2d | 40d | 0d | start no earlier than 2013-09-02 | Roberta [50%] | 64h |  |
| 53 | 3.2.2.1.5 | Regression testing complete | milestone | 0d | 2013-11-01 | 2013-11-01 | 52, 49, 50, 51 |  |  | 2013-10-30 | 2013-10-30 | 0d | 50.5d | 11d |  |  |  |  |

Notes:
- 50: will be done after testing of Advising Notes ETA TBD / estimates are with assumption of jack testing at 100%. needs to be changed if he is working less.
- 51: Don't need to deploy until November so will test later / estimates are with assumption of jack testing at 100%. needs to be changed if he is working less.

| ID | WBS | Task | Type | Duration | Start | Finish | Predecessors | Complete | Remaining | Baseline start | Baseline finish | Baseline duration | Total slack | Free slack | Constraint | Resources | Work | Actual work |
| --- | --- | --- | --- | --- | --- | --- | --- | --- | --- | --- | --- | --- | --- | --- | --- | --- | --- | --- |
| 54 | 3.2.2.2 | **User Testing** |  | 60d | 2013-08-27 A | 2013-11-18 |  | 37% | 37.63d |  |  |  | 39.5d |  |  |  | 472h | 176h |
| 55 | 3.2.2.2.1 | Test Advisor Assignment |  | 19d | 2013-08-27 A | 2013-09-23 A | 49 | 100% |  |  |  |  |  |  | start no earlier than 2013-08-27 | Brian | 152h | 152h |
| 56 | 3.2.2.2.2 | Test Instructor Assignment |  | 10d | 2013-09-30 A | 2013-10-11 | 50FS+1d, 55 | 30% | 7d |  |  |  | 45d | 15d |  | Brian | 80h | 24h |
| 57 | 3.2.2.2.3 | Test Supervisor Assignment |  | 10d | 2013-11-04 | 2013-11-18 | 51, 56 |  |  |  |  |  | 30d | 0d |  | Brian | 80h |  |
| 58 | 3.2.2.2.4 | Test Reg Control List |  | 20d | 2013-09-30 | 2013-10-28 | 52FS+3d |  |  |  |  |  | 41d | 0d |  | Brian | 160h |  |
| 59 | 3.2.2.2.5 | User Testing Complete | milestone | 0d | 2013-11-18 | 2013-11-18 | 55, 56, 57, 58 |  |  |  |  |  | 39.5d | 0d |  | Brian |  |  |
| 60 | 3.2.2.3 | Testing complete | milestone | 0d | 2013-11-18 | 2013-11-18 | 53, 59 |  |  |  |  |  | 39.5d |  |  |  |  |  |
| 61 | 3.2.3 | **Deployment Preparation** |  | 55d | 2013-10-28 | 2014-01-10 |  |  |  |  |  |  | 0.5d |  |  |  | 42h |  |
| 62 | 3.2.3.1 | **Instructor and Supervisor Assignment** |  | 8d | 2013-11-13 | 2013-11-22 |  |  |  |  |  |  | 33d |  |  |  | 16h |  |
| 63 | 3.2.3.1.1 | Create deployment plan |  | 7d | 2013-11-13 | 2013-11-21 | 57FS-4d |  |  |  |  |  | 33d | 0d |  | René [25%] | 14h |  |
| 64 | 3.2.3.1.2 | Review deployment plan with participants |  | 1d | 2013-11-22 | 2013-11-22 | 63 |  |  |  |  |  | 35d | 0d |  | René [25%] | 2h |  |
| 65 | 3.2.3.1.3 | Instructor and Superviosr Assignment deployment plan complete | milestone | 0d | 2013-11-22 | 2013-11-22 | 64 |  |  |  |  |  | 35d | 0d |  | René [25%] |  |  |
| 66 | 3.2.3.2 | **Reg Control List** |  | 5d | 2013-10-28 | 2013-11-01 |  |  |  |  |  |  | 50d |  |  |  | 10h |  |
| 67 | 3.2.3.2.1 | Create deployment plan |  | 4d | 2013-10-28 | 2013-10-31 | 58FS-1d |  |  |  |  |  | 50d | 0d |  | René [25%] | 8h |  |
| 68 | 3.2.3.2.2 | Review deployment plan with participants |  | 1d | 2013-11-01 | 2013-11-01 | 67 |  |  |  |  |  | 50d | 0d |  | René [25%] | 2h |  |
| 69 | 3.2.3.2.3 | Instructor and Superviosr Assignment deployment plan complete | milestone | 0d | 2013-11-01 | 2013-11-01 | 68 |  |  |  |  |  | 50d | 0d |  | René [25%] |  |  |
| 70 | 3.2.3.3 | **Advisor Assignment** |  | 10d | 2013-12-30 | 2014-01-10 |  |  |  |  |  |  | 0.5d |  |  |  | 16h |  |
| 71 | 3.2.3.3.1 | Create deployment plan |  | 7d | 2013-12-30 | 2014-01-09 | 55FS+69d |  |  |  |  |  | 0.5d | 0d |  | René [25%] | 14h |  |
| 72 | 3.2.3.3.2 | Review deployment plan with participants |  | 1d | 2014-01-10 | 2014-01-10 | 71 |  |  |  |  |  | 0.5d | 0d |  | René [25%] | 2h |  |
| 73 | 3.2.3.3.3 | Instructor and Superviosr Assignment deployment plan complete | milestone | 0d | 2014-01-10 | 2014-01-10 | 72 |  |  |  |  |  | 0.5d | 0d |  | René [25%] |  |  |
| 74 | 3.2.3.4 | Deployment planning complete | milestone | 0d | 2014-01-10 | 2014-01-10 | 65, 69, 73 |  |  |  |  |  | 0.5d |  |  | René [25%] |  |  |
| 75 | 3.2.4 | **Deployments** |  | 50.5d | 2013-11-04 | 2014-01-13 |  |  |  | 2013-11-04 | 2014-01-13 | 50.5d | 0d |  |  |  | 3h |  |
| 76 | 3.2.4.1 | Deploy Instructor and Supervisor Assignment |  | 0.5d | 2013-11-25 | 2013-11-25 | 56, 57, 65 |  |  | 2013-11-25 | 2013-11-25 | 0.5d | 35d |  | start no earlier than 2013-11-25 | René [25%] | 1h |  |
| 77 | 3.2.4.2 | Deploy Reg Control List |  | 0.5d | 2013-11-04 | 2013-11-04 | 58, 69 |  |  | 2013-11-04 | 2013-11-04 | 0.5d | 50d |  | start no earlier than 2013-11-04 | René [25%] | 1h |  |
| 78 | 3.2.4.3 | Deploy Advisor Assignment |  | 0.5d | 2014-01-13 | 2014-01-13 | 55, 71 |  |  | 2014-01-13 | 2014-01-13 | 0.5d | 0d |  | start no earlier than 2014-01-13 | René [25%] | 1h |  |
| 79 | 3.2.4.4 | Deployments complete | milestone | 0d | 2014-01-13 | 2014-01-13 | 76, 77, 78 |  |  | 2014-01-13 | 2014-01-13 | 0d | 0d |  |  | René [25%] |  |  |
| 80 | 3.2.5 | Bundle 1 complete | milestone | 0d | 2014-01-13 | 2014-01-13 | 79 |  |  | 2014-01-13 | 2014-01-13 | 0d | 0d |  |  | René [25%] |  |  |

| ID | WBS | Task | Type | Duration | Start | Finish | Predecessors | Complete | Remaining | Baseline start | Baseline finish | Baseline duration | Total slack | Free slack | Constraint | Resources | Work | Actual work |
| --- | --- | --- | --- | --- | --- | --- | --- | --- | --- | --- | --- | --- | --- | --- | --- | --- | --- | --- |
| 81 | 4 | **PE REG Upgrade** |  | 241d? | 2013-01-14 A | 2013-12-16 |  | 61% | 92.87d? | 2013-01-14 | 2013-12-16 | 241d? | 19.5d |  |  |  | 982h | 458h |
| 82 | 4.1 | **Phase I - Java 6, Touchstone, and CSF Enabling** |  | 54d | 2013-02-07 A | 2013-04-23 A |  | 100% |  | 2013-02-07 | 2013-03-07 | 21d? |  |  |  |  | 386h | 386h |
| 83 | 4.1.1 | **Development** |  | 27d | 2013-02-07 A | 2013-03-15 A |  | 100% |  | 2013-02-07 | 2013-03-07 | 21d |  |  |  |  | 208h | 208h |
| 84 | 4.1.1.1 | Do set-up and configuration required for upgrade |  | 5d | 2013-02-07 A | 2013-02-13 A |  | 100% |  | 2013-02-07 | 2013-02-13 | 5d |  |  |  | Ram | 40h | 40h |
| 85 | 4.1.1.2 | Perform upgrade |  | 9d | 2013-02-14 A | 2013-02-27 A | 84 | 100% |  | 2013-02-14 | 2013-02-21 | 5d |  |  |  | Ram | 72h | 72h |
| 86 | 4.1.1.3 | Unit test changes |  | 12d | 2013-02-28 A | 2013-03-15 A | 85 | 100% |  | 2013-02-22 | 2013-03-07 | 10d |  |  |  | Ram | 96h | 96h |
| 87 | 4.1.2 | **Testing** |  | 45d | 2013-02-20 A | 2013-04-23 A |  | 100% |  |  |  |  |  |  |  |  | 146h | 146h |
| 88 | 4.1.2.1 | Test planning |  | 12d | 2013-02-20 A | 2013-03-07 A | 85SS+4d | 100% |  |  |  |  |  |  |  | Debra [25%] | 24h | 24h |
| 89 | 4.1.2.2 | QA testing |  | 12d | 2013-03-18 A | 2013-04-02 A | 88, 86 | 100% |  |  |  |  |  |  |  | Debra [25%] | 24h | 24h |
| 90 | 4.1.2.3 | Load testing |  | 5d | 2013-04-04 A | 2013-04-10 A | 89FS+1d | 100% |  |  |  |  |  |  |  | Steve [25%] | 10h | 10h |
| 91 | 4.1.2.4 | User testing |  | 11d | 2013-04-09 A | 2013-04-23 A | 89FS+4d | 100% |  |  |  |  |  |  |  | Carrie | 88h | 88h |
| 92 | 4.1.3 | **Deployment Preparation** |  | 4d | 2013-04-16 A | 2013-04-19 A |  | 100% |  |  |  |  |  |  |  |  | 32h | 32h |
| 93 | 4.1.3.1 | Create deployment plan |  | 4d | 2013-04-16 A | 2013-04-19 A | 91SS | 100% |  |  |  |  |  |  |  | René | 32h | 32h |
| 94 | 4.2 | **Optimization** |  | 65d | 2013-05-13 A | 2013-08-09 A |  | 100% |  |  |  |  |  |  |  |  | 48h | 48h |
| 95 | 4.2.1 | Perform analysis/solution design |  | 30d | 2013-05-13 A | 2013-06-21 A |  | 100% |  |  |  |  |  |  | start no earlier than 2013-05-13 |  |  |  |
| 96 | 4.2.2 | Make coding changes |  | 5d | 2013-06-24 A | 2013-06-28 A | 95 | 100% |  |  |  |  |  |  |  |  |  |  |
| 97 | 4.2.3 | Do SIT |  | 2d | 2013-07-08 A | 2013-07-09 A | 96 | 100% |  |  |  |  |  |  |  |  |  |  |
| 98 | 4.2.4 | Do UAT |  | 10d | 2013-07-17 A | 2013-08-08 A | 97FS+5d | 100% |  |  |  |  |  |  |  |  |  |  |
| 99 | 4.2.5 | **Deployment Prepration** |  | 6d | 2013-07-24 A | 2013-07-31 A |  | 100% |  |  |  |  |  |  |  |  | 48h | 48h |
| 100 | 4.2.5.1 | Review deployment plan with participants |  | 6d | 2013-07-24 A | 2013-07-31 A | 98SS+5d | 100% |  |  |  |  |  |  |  | René | 48h | 48h |
| 101 | 4.2.6 | Go-live | milestone | 0d | 2013-08-09 A | 2013-08-09 A | 100, 98 | 100% |  |  |  |  |  |  |  |  |  |  |
| 102 | 4.3 | **Phase II - Full CSF Upgrade** |  | 241d? | 2013-01-14 A | 2013-12-16 |  | 4% | 232.18d? | 2013-01-14 | 2013-12-16 | 241d? | 19.5d |  |  |  | 548h | 24h |
| 103 | 4.3.1 | **Development** |  | 45d | 2013-08-21 A | 2013-10-22 |  | 7% | 41.86d | 2013-08-21 | 2013-10-22 | 45d | 16.5d |  |  |  | 344h | 24h |
| 104 | 4.3.1.1 | Ramp up |  | 3d | 2013-08-21 A | 2013-08-23 A |  | 100% |  | 2013-08-21 | 2013-08-23 | 3d |  |  | start no earlier than 2013-08-21 | Ram | 24h | 24h |
| 105 | 4.3.1.2 | Update applicationContext files and reorganize |  | 1d | 2013-08-26 | 2013-08-26 | 104 |  |  | 2013-08-26 | 2013-08-26 | 1d | 16.5d | 0d |  | Ram | 8h |  |
| 106 | 4.3.1.3 | Make changes to DAO modules (21 modules) |  | 12d | 2013-08-27 | 2013-09-12 | 105 |  |  | 2013-08-27 | 2013-09-12 | 12d | 15.5d | 0d |  | Ram | 96h |  |
| 107 | 4.3.1.4 | Fix service modules unit tests and create new unit tests for DAO |  | 18d | 2013-09-13 | 2013-10-08 | 106 |  |  | 2013-09-13 | 2013-10-08 | 18d | 15.5d | 0d |  | Ram | 144h |  |
| 108 | 4.3.1.5 | Replace sfbreCurrentPerson domain object and related objects and mappings |  | 4d | 2013-10-09 | 2013-10-15 | 107 |  |  | 2013-10-09 | 2013-10-15 | 4d | 15.5d | 0d |  | Ram | 32h |  |
| 109 | 4.3.1.6 | Rewrite the email codes to use the new csf email service |  | 5d | 2013-10-16 | 2013-10-22 | 86, 108 |  |  | 2013-10-16 | 2013-10-22 | 5d | 15.5d | 0d |  | Ram | 40h |  |
| 110 | 4.3.1.7 | Development complete | milestone | 0d | 2013-10-22 | 2013-10-22 | 109 |  |  | 2013-10-22 | 2013-10-22 | 0d | 16.5d | 0d |  | Ram |  |  |

Notes:
- 109: Is only needed if pereg uses a bulk email service.

| ID | WBS | Task | Type | Duration | Start | Finish | Predecessors | Complete | Baseline start | Baseline finish | Baseline duration | Total slack | Free slack | Constraint | Resources | Work | Actual work |
| --- | --- | --- | --- | --- | --- | --- | --- | --- | --- | --- | --- | --- | --- | --- | --- | --- | --- |
| 111 | 4.3.2 | **Testing** |  | 30d? | 2013-10-23 | 2013-12-03 |  |  | 2013-10-23 | 2013-12-03 | 30d? | 16.5d |  |  |  | 116h |  |
| 112 | 4.3.2.1 | Do test planning |  | 2d | 2013-10-23 | 2013-10-24 | 110 |  | 2013-10-23 | 2013-10-24 | 2d | 16.5d | 0d |  | Jack [50%] | 8h |  |
| 113 | 4.3.2.2 | Execute regression test |  | 23d | 2013-10-25 | 2013-11-27 | 112 |  | 2013-10-25 | 2013-11-27 | 23d | 16.5d | 2d |  | Jack [50%] | 92h |  |
| 114 | 4.3.2.3 | Perform user test |  | 1d? | 2013-12-02 | 2013-12-02 | 113 |  | 2013-12-02 | 2013-12-02 | 1d? | 28.5d | 0d |  | Carrie | 8h |  |
| 115 | 4.3.2.4 | Perform load test |  | 1d? | 2013-12-03 | 2013-12-03 | 114 |  | 2013-12-03 | 2013-12-03 | 1d? | 28.5d |  |  | Steve | 8h |  |
| 116 | 4.3.3 | **Deployment Preparation** |  | 11d | 2013-12-02 | 2013-12-16 |  |  | 2013-12-02 | 2013-12-16 | 11d | 15.5d |  |  |  | 88h |  |
| 117 | 4.3.3.1 | Create deployment plan |  | 10d | 2013-12-02 | 2013-12-13 | 113 |  | 2013-12-02 | 2013-12-13 | 10d | 15.5d | 0d |  | René | 80h |  |
| 118 | 4.3.3.2 | Review deployment plan with participants |  | 1d | 2013-12-16 | 2013-12-16 | 117 |  | 2013-12-16 | 2013-12-16 | 1d | 19.5d |  |  | René | 8h |  |
| 119 | 4.3.4 | Go-live |  | 1d? | 2013-01-14 | 2013-01-14 |  |  | 2013-01-14 | 2013-01-14 | 1d? | 259.5d | 0d |  |  |  |  |
| 120 | 4.3.5 | PE REG upgrade complete | milestone | 0d | 2013-01-14 | 2013-01-14 | 119 |  | 2013-01-14 | 2013-01-14 | 0d | 259.5d |  |  | Ram |  |  |
| 121 | 5 | **OREG to Conversion to CSF 2.0** |  | 90d | 2013-02-11 A | 2013-06-14 A |  | 100% | 2013-02-11 | 2013-05-28 | 76d |  |  |  |  | 790h | 790h |
| 122 | 5.1 | **Development (including unit testing)** |  | 37d | 2013-02-11 A | 2013-04-02 A |  | 100% | 2013-02-11 | 2013-03-22 | 29d |  |  |  |  | 400h | 400h |
| 123 | 5.1.1 | Phase 1 - Required as-is , high priority (A/D and OREG) |  | 9d | 2013-02-11 A | 2013-02-22 A |  | 100% |  |  |  |  |  | start no earlier than 2013-02-11 | Felicia | 72h | 72h |
| 124 | 5.1.2 | Phase 2 - Medium priority validation and messaging |  | 18d | 2013-02-25 A | 2013-03-20 A | 123 | 100% |  |  |  |  |  |  | Felicia | 144h | 144h |
| 125 | 5.1.3 | Phase 3 - Stabilize JAR and rafactor CSF dependencies |  | 8d | 2013-03-13 A | 2013-03-22 A | 124FS-6d | 100% |  |  |  |  |  |  | Felicia | 64h | 64h |
| 126 | 5.1.4 | Phase 4 - Modify OREG to use new JAR and upgrade to CSF 2.0 |  | 15d | 2013-03-13 A | 2013-04-02 A | 125SS | 100% |  |  |  |  |  |  | Felicia | 120h | 120h |
| 127 | 5.1.5 | OREG conversion development complete | milestone | 0d | 2013-04-02 A | 2013-04-02 A | 126 | 100% |  |  |  |  |  |  | Felicia |  |  |
| 128 | 5.2 | Regression Testing |  | 24d | 2013-04-01 A | 2013-05-03 A | 127FS-2d | 100% | 2013-03-25 | 2013-04-26 | 24d |  |  |  | Kevin | 192h | 192h |
| 129 | 5.3 | UAT |  | 15d | 2013-04-29 A | 2013-05-17 A | 128FS-5d | 100% | 2013-04-29 | 2013-05-24 | 20d |  |  |  | Peter [25%] | 30h | 30h |
| 130 | 5.4 | **Deployment Preparation** |  | 11d | 2013-04-29 A | 2013-05-13 A |  | 100% |  |  |  |  |  |  |  | 88h | 88h |
| 131 | 5.4.1 | Create deployment plan |  | 5d | 2013-04-29 A | 2013-05-03 A | 129SS | 100% |  |  |  |  |  |  | René | 40h | 40h |
| 132 | 5.4.2 | Review deployment plan with participants |  | 1d | 2013-05-06 A | 2013-05-06 A | 131 | 100% |  |  |  |  |  |  | René | 8h | 8h |
| 133 | 5.4.3 | Create registration support plan |  | 5d | 2013-05-07 A | 2013-05-13 A | 132 | 100% |  |  |  |  |  |  | René | 40h | 40h |
| 134 | 5.5 | Go-live | milestone | 0d | 2013-05-21 A | 2013-05-21 A | 129FS+2d | 100% | 2013-05-28 | 2013-05-28 | 0d |  |  |  | René |  |  |
| 135 | 5.6 | Prod smoke test | milestone | 0d | 2013-05-21 A | 2013-05-21 A | 134 | 100% |  |  |  |  |  |  | Peter |  |  |
| 136 | 5.7 | Registration opens | milestone | 0d | 2013-06-03 A | 2013-06-03 A |  | 100% |  |  |  |  |  | start no earlier than 2013-06-03 | Peter |  |  |
| 137 | 5.8 | Registration support |  | 10d | 2013-06-03 A | 2013-06-14 A | 136 | 100% |  |  |  |  |  |  | René | 80h | 80h |

| ID | WBS | Task | Type | Duration | Start | Finish | Predecessors | Complete | Constraint | Resources | Work | Actual work |
| --- | --- | --- | --- | --- | --- | --- | --- | --- | --- | --- | --- | --- |
| 138 | 6 | **Notes Utility Beta** |  | 80d | 2013-02-25 A | 2013-06-14 A |  | 100% |  |  | 666h | 666h |
| 139 | 6.1 | **Functional Specs** |  | 26.25d | 2013-02-25 A | 2013-04-02 A |  | 100% |  |  | 178h | 178h |
| 140 | 6.1.1 | Write functional specs |  | 17d | 2013-02-25 A | 2013-03-19 A |  | 100% |  | Seth | 136h | 136h |
| 141 | 6.1.2 | Have team review of functional specs |  | 0.25d | 2013-03-22 A | 2013-03-22 A | 140FS+2d | 100% |  | Seth | 2h | 2h |
| 142 | 6.1.3 | Get sponsor approval on functional spec |  | 5d | 2013-03-26 A | 2013-04-02 A | 141FS+2d | 100% |  | René | 40h | 40h |
| 143 | 6.1.4 | Functional specs complete | milestone | 0d | 2013-04-02 A | 2013-04-02 A | 142 | 100% |  | Seth |  |  |
| 144 | 6.2 | Development |  | 26d | 2013-04-03 A | 2013-05-09 A | 122, 143 | 100% |  | Felicia | 208h | 208h |
| 145 | 6.3 | IS&T validate notes on desktop |  | 1d | 2013-04-29 A | 2013-04-29 A | 144 | 100% |  | René [25%] | 2h | 2h |
| 146 | 6.4 | UAT |  | 15d | 2013-04-29 A | 2013-05-17 A | 145SS | 100% |  | Peter [25%] | 30h | 30h |
| 147 | 6.5 | **Deployment Preparation** |  | 12d | 2013-04-29 A | 2013-05-14 A |  | 100% |  |  | 168h | 168h |
| 148 | 6.5.1 | Create deployment plan |  | 10d | 2013-04-29 A | 2013-05-10 A | 131SS | 100% |  | René | 80h | 80h |
| 149 | 6.5.2 | Review deployment plan with participants |  | 1d | 2013-05-14 A | 2013-05-14 A | 148 | 100% |  | René | 8h | 8h |
| 150 | 6.5.3 | Create registration support plan |  | 10d | 2013-05-01 A | 2013-05-14 A | 148SS+2d | 100% |  | René | 80h | 80h |
| 151 | 6.6 | Go-live | milestone | 0d | 2013-05-21 A | 2013-05-21 A | 146FS+2d | 100% |  | René |  |  |
| 152 | 6.7 | Prod smoke test | milestone | 0d | 2013-05-21 A | 2013-05-21 A | 151 | 100% |  | Peter |  |  |
| 153 | 6.8 | Registration opens | milestone | 0d | 2013-06-03 A | 2013-06-03 A |  | 100% | start no earlier than 2013-06-03 | Peter |  |  |
| 154 | 6.9 | Registration support |  | 10d | 2013-06-03 A | 2013-06-14 A | 153 | 100% |  | René | 80h | 80h |

Notes:
- 145: Make sure a non-author can't access notes by manually entering in page(s) notes appear on (Subject Selection and Summary)
